# Remaining Activities of Froozan Jackets-90 days duration

Schedule from Primavera P6, 2024-07-06 to 2024-10-02, data date 2024-07-06.

## Calendars

- Froozan: Mon-Thu 06:00-12:00, 14:00-18:00; Fri 06:00-12:00; Sat-Sun 06:00-12:00, 14:00-18:00. Exceptions (off unless hours are given): 2024-07-16.

## Resources

| Resource | Group |
| --- | --- |
| Painting Team | labor |
| Helper | labor |
| Cutter | labor |
| QC | labor |
| Welder | labor |
| Fitter | labor |
| Scaffolding Team | labor |
| Grinder | labor |

## Schedule

| ID | WBS | Activity | Type | Duration | Start | Finish | Predecessors | Total float | Free float | Constraint | Resources |
| --- | --- | --- | --- | --- | --- | --- | --- | --- | --- | --- | --- |
|  | 1 | **Milestones** |  |  | 2024-07-06 | 2024-10-02 |  |  |  |  |  |
| FJ90.1.1 |  | Project Start | milestone | 0d | 2024-07-06 | 2024-07-06 |  | 0d |  |  |  |
| FJ90.1.2 |  | Project Finish | milestone | 0d | 2024-10-02 | 2024-10-02 | FJ90.7.1 FF | 0d |  |  |  |
| FJ90.1.3 |  | FXA Jacket Finish |  | 0d | 2024-10-02 | 2024-10-02 | FJ90.3.1.2 | 0d |  |  |  |
| FJ90.1.4 |  | F19 Jacket Finnish |  | 0d | 2024-10-02 | 2024-10-02 | FJ90.4.1.2 | 0d |  |  |  |
|  | 3 | **Shoetage Material** |  |  | 2024-07-21 | 2024-08-21 |  |  |  |  |  |
| FJ90.1.3.2 |  | Caisson (Cone , Elbow, Tube)(FXA,F19) |  | 0d | 2024-07-21 | 2024-07-21 | FJ90.1.1 SS | 0d | 33.78d | start on 2024-07-21 |  |
| FJ90.1.3.3 |  | Crown Plate (FXA, F19) |  | 0d | 2024-07-21 | 2024-07-21 | FJ90.1.1 SS+14d | 0d | 51.89d | start on 2024-07-21 |  |
| FJ90.1.3.4 |  | Flooding System (Ball Valve, Elbow, Flange, Quick Coupling, Tube)(FXA, F19) |  | 0d | 2024-07-21 | 2024-07-21 | FJ90.1.1 SS+14d | 0d | 29.78d | start on 2024-07-21 |  |
| FJ90.1.3.5 |  | Buoyancy Tank (Cone, Tube)(FXA, F19) |  | 0d | 2024-07-21 | 2024-07-21 | FJ90.1.1 SS+14d | 0d | 40.22d | start on 2024-07-21 |  |
| FJ90.1.3.6 |  | Rubber Diaphragm (FXA,F19) |  | 0d | 2024-07-31 | 2024-07-31 | FJ90.1.1 SS+14d | 0d | 65.67d | start on 2024-07-31 |  |
| FJ90.1.3.7 |  | Anode(10 PCS)(FXA, F19) |  | 0d | 2024-08-03 | 2024-08-03 | FJ90.1.1 SS+7d | 0d |  | start on 2024-08-03 |  |
| FJ90.1.3.1 |  | Riser(Flang, Anchore Flange)(FXA, F19) |  | 0d | 2024-08-21 | 2024-08-21 |  | 0d | 1.11d | start on 2024-08-21 |  |
|  | 2 | **Mobilization** |  |  | 2024-07-06 | 2024-07-06 |  |  |  |  |  |
| FJ90.2.1 |  | Mobilization |  | 0d | 2024-07-06 | 2024-07-06 | FJ90.1.1 SS | 0d |  |  |  |
|  | 3 | **FXA** |  |  | 2024-07-06 | 2024-10-02 |  |  |  |  |  |
|  | 1 | **Paint** |  |  | 2024-09-24 | 2024-10-02 |  |  |  |  |  |
| FJ90.3.1.1 |  | Blasting |  | 4d | 2024-09-24 | 2024-09-28 | FJ90.3.24.1 | 0d |  |  | Painting Team [36 h] |
| FJ90.3.1.2 |  | Painting |  | 4d | 2024-09-28 | 2024-10-02 | FJ90.3.1.1 | 0d |  |  | Painting Team [36 h] |
|  | 2 | **Anode** |  |  | 2024-07-13 | 2024-08-16 |  |  |  |  |  |
|  | 1 | **Assembled Anode(20 PCS)** |  |  | 2024-07-13 | 2024-07-23 |  |  |  |  |  |
| FJ90.3.2.1.1 |  | welding |  | 8d | 2024-07-13 | 2024-07-22 | FJ90.2.1 FS+7d, FJ90.4.2.1.1 | 49.44d | 0d |  | Welder [40 h]; Helper [40 h] |
| FJ90.3.2.1.2 |  | QC |  | 2d | 2024-07-22 | 2024-07-23 | FJ90.3.2.1.1 | 49.44d | 10.56d |  | QC [18 h] |
|  | 2 | **New Anode Installation(35 PCS)** |  |  | 2024-08-03 | 2024-08-16 |  |  |  |  |  |
| FJ90.3.2.2.1 |  | Assembly |  | 6d | 2024-08-03 | 2024-08-08 | FJ90.3.2.1.2, FJ90.1.3.7 | 38.89d | 0d |  | Fitter [40 h]; Helper [54 h] |
| FJ90.3.2.2.2 |  | Welding |  | 6d | 2024-08-08 | 2024-08-14 | FJ90.3.2.2.1 | 38.89d | 0d |  | Welder [54 h]; Helper [54 h] |
| FJ90.3.2.2.3 |  | QC |  | 2d | 2024-08-14 | 2024-08-16 | FJ90.3.2.2.2 | 38.89d |  |  | QC [18 h] |

| ID | WBS | Activity | Duration | Start | Finish | Predecessors | Total float | Free float | Resources |
| --- | --- | --- | --- | --- | --- | --- | --- | --- | --- |
|  | 3 | **Riser** |  | 2024-08-02 | 2024-09-03 |  |  |  |  |
|  | 1 | **Sandblasting** |  | 2024-08-02 | 2024-08-10 |  |  |  |  |
| FJ90.3.3.1.1 |  | Sandblast | 8d | 2024-08-02 | 2024-08-10 | FJ90.3.4.2.2 | 1.44d | 0d | Painting Team [72 h] |
|  | 2 | **Fabrication** |  | 2024-08-10 | 2024-08-20 |  |  |  |  |
| FJ90.3.3.2.1 |  | Assembly | 4d | 2024-08-10 | 2024-08-13 | FJ90.3.3.1.1 | 1.44d | 0d | Fitter [27 h]; Helper [27 h] |
| FJ90.3.3.2.2 |  | Welding | 6d | 2024-08-13 | 2024-08-18 | FJ90.3.3.2.1 FS-1d | 1.44d | 0d | Welder [45 h]; Helper [45 h] |
| FJ90.3.3.2.3 |  | NDT/QC | 2d | 2024-08-18 | 2024-08-20 | FJ90.3.3.2.2 | 1.44d | 0d | QC [18 h] |
|  | 3 | **Installation** |  | 2024-08-22 | 2024-09-03 |  |  |  |  |
| FJ90.3.3.3.1 |  | Scaffolding | 2d | 2024-08-22 | 2024-08-24 | FJ90.3.3.2.3, FJ90.1.3.1, FJ90.3.4.2.4, FJ90.3.18.1.4, FJ90.3.19.1.4, FJ90.3.13.2.5 | 0d |  | Scaffolding Team [18 h] |
| FJ90.3.3.3.2 |  | Assembly | 4d | 2024-08-24 | 2024-08-27 | FJ90.3.3.3.1 | 0d |  | Fitter [40 h]; Helper [40 h] |
| FJ90.3.3.3.3 |  | Welding | 4d | 2024-08-27 | 2024-08-31 | FJ90.3.3.3.2 | 0d |  | Welder [18 h]; Helper [18 h] |
| FJ90.3.3.3.4 |  | Hydro Test | 1d | 2024-08-31 | 2024-09-01 | FJ90.3.3.3.3 | 0d |  | QC [9 h]; Grinder [9 h]; Welder [9 h] |
| FJ90.3.3.3.5 |  | NDT/QC | 2d | 2024-09-01 | 2024-09-03 | FJ90.3.3.3.4 | 0d |  | QC [18 h] |
|  | 4 | **Riser Clamp** |  | 2024-07-06 | 2024-08-13 |  |  |  |  |
|  | 1 | **Fabrication** |  | 2024-07-06 | 2024-07-23 |  |  |  |  |
| FJ90.3.4.1.1 |  | Assembly | 6d | 2024-07-06 | 2024-07-11 | FJ90.2.1 | 0d |  | Fitter [90 h]; Helper [90 h] |
| FJ90.3.4.1.2 |  | Welding | 10d | 2024-07-11 | 2024-07-22 | FJ90.3.4.1.1 | 0d |  | Welder [108 h]; Helper [108 h] |
| FJ90.3.4.1.3 |  | NDT/Qc | 2d | 2024-07-22 | 2024-07-23 | FJ90.3.4.1.2 | 0d |  | QC [18 h] |
|  | 2 | **Installation** |  | 2024-07-24 | 2024-08-13 |  |  |  |  |
| FJ90.3.4.2.1 |  | Scaffolding | 2d | 2024-07-24 | 2024-07-25 | FJ90.3.4.1.3 | 1.44d | 0d | Scaffolding Team [18 h] |
| FJ90.3.4.2.2 |  | Assembly | 8d | 2024-07-25 | 2024-08-02 | FJ90.3.4.2.1 | 1.44d | 0d | Fitter [90 h]; Helper [90 h] |
| FJ90.3.4.2.3 |  | Welding | 10d | 2024-08-02 | 2024-08-12 | FJ90.3.4.2.2 | 8.44d | 0d | Welder [90 h]; Helper [90 h] |
| FJ90.3.4.2.4 |  | NDT/QC | 2d | 2024-08-12 | 2024-08-13 | FJ90.3.4.2.3 | 8.44d |  | QC [18 h] |
|  | 5 | **Barge bumper** |  | 2024-07-22 | 2024-09-08 |  |  |  |  |
|  | 1 | **Sandblasting & Painting** |  | 2024-07-22 | 2024-07-27 |  |  |  |  |
| FJ90.3.5.1.1 |  | Sandblasting & Painting | 6d | 2024-07-22 | 2024-07-27 | FJ90.3.4.1.1, FJ90.3.4.1.2 | 0d |  | Painting Team [36 h] |

| ID | WBS | Activity | Duration | Start | Finish | Predecessors | Total float | Free float | Resources |
| --- | --- | --- | --- | --- | --- | --- | --- | --- | --- |
|  | 2 | **BB Structure** |  | 2024-07-28 | 2024-09-08 |  |  |  |  |
|  | 1 | **Fabrication** |  | 2024-07-28 | 2024-08-04 |  |  |  |  |
| FJ90.3.5.2.1.1 |  | Assembly | 2d | 2024-07-28 | 2024-07-29 | FJ90.3.5.1.1 | 0d |  | Fitter [18 h]; Helper [18 h] |
| FJ90.3.5.2.1.2 |  | Welding | 4d | 2024-07-29 | 2024-08-02 | FJ90.3.5.2.1.1 | 0d |  | Welder [18 h]; Helper [18 h] |
| FJ90.3.5.2.1.3 |  | NDT/QC | 2d | 2024-08-02 | 2024-08-04 | FJ90.3.5.2.1.2 | 5.22d | 4d | QC [9 h] |
|  | 2 | **Installation** |  | 2024-09-04 | 2024-09-08 |  |  |  |  |
| FJ90.3.5.2.2.1 |  | Assembly | 2d | 2024-09-04 | 2024-09-05 | FJ90.3.5.2.1.3, FJ90.3.5.3.2.4 | 0d |  | Fitter [18 h]; Helper [18 h] |
| FJ90.3.5.2.2.2 |  | Welding | 2d | 2024-09-05 | 2024-09-07 | FJ90.3.5.2.2.1 | 0d |  | Welder [18 h]; Helper [18 h] |
| FJ90.3.5.2.2.3 |  | NDT/QC | 1d | 2024-09-08 | 2024-09-08 | FJ90.3.5.2.2.2 | 0d |  | QC |
|  | 3 | **BB Supports** |  | 2024-08-02 | 2024-09-03 |  |  |  |  |
|  | 1 | **Fabrication** |  | 2024-08-02 | 2024-08-15 |  |  |  |  |
| FJ90.3.5.3.1.1 |  | Assembly | 5d | 2024-08-02 | 2024-08-07 | FJ90.3.5.2.1.2 | 0d |  | Fitter [54 h]; Helper [54 h] |
| FJ90.3.5.3.1.2 |  | Welding | 7d | 2024-08-07 | 2024-08-13 | FJ90.3.5.3.1.1 | 0d |  | Welder [72 h]; Helper [72 h] |
| FJ90.3.5.3.1.3 |  | NDT/QC | 2d | 2024-08-14 | 2024-08-15 | FJ90.3.5.3.1.2 | 0d |  | QC [18 h] |
|  | 2 | **Installation** |  | 2024-08-15 | 2024-09-03 |  |  |  |  |
| FJ90.3.5.3.2.1 |  | Scaffolding | 2d | 2024-08-15 | 2024-08-17 | FJ90.3.5.3.1.3 | 0d |  | Scaffolding Team [18 h] |
| FJ90.3.5.3.2.2 |  | Assembly | 8d | 2024-08-18 | 2024-08-25 | FJ90.3.5.3.2.1 | 0d |  | Fitter [72 h]; Helper [72 h] |
| FJ90.3.5.3.2.3 |  | Welding | 8d | 2024-08-25 | 2024-09-02 | FJ90.3.5.3.2.2 | 0d |  | Welder [72 h]; Helper [72 h] |
| FJ90.3.5.3.2.4 |  | NDT/QC | 2d | 2024-09-02 | 2024-09-03 | FJ90.3.5.3.2.3 | 0d |  | QC [18 h] |
|  | 6 | **Boat Landing** |  | 2024-07-28 | 2024-09-07 |  |  |  |  |
|  | 1 | **BL Structure** |  | 2024-07-28 | 2024-09-07 |  |  |  |  |
| FJ90.3.6.1.1 |  | Sandblasting & Painting | 4d | 2024-07-28 | 2024-07-31 | FJ90.3.5.1.1 | 2d | 0d | Painting Team [40 h] |
| FJ90.3.6.1.2 |  | Trial Installation | 4d | 2024-09-03 | 2024-09-07 | FJ90.3.6.2.2.4 | 2d |  | Welder [40 h]; Helper [40 h]; QC [40 h]; Fitter [40 h] |
|  | 2 | **BL Supports** |  | 2024-07-31 | 2024-09-03 |  |  |  |  |
|  | 1 | **Fabrication** |  | 2024-07-31 | 2024-08-15 |  |  |  |  |
| FJ90.3.6.2.1.1 |  | Assembly | 6d | 2024-07-31 | 2024-08-06 | FJ90.3.6.1.1 | 2d | 0d | Fitter [54 h]; Helper [54 h] |
| FJ90.3.6.2.1.2 |  | Welding | 8d | 2024-08-06 | 2024-08-13 | FJ90.3.6.2.1.1 | 2d | 0d | Welder [72 h]; Helper [72 h] |
| FJ90.3.6.2.1.3 |  | NDT/QC | 2d | 2024-08-14 | 2024-08-15 | FJ90.3.6.2.1.2 | 2d | 0d | QC [18 h] |

| ID | WBS | Activity | Duration | Start | Finish | Predecessors | Total float | Free float | Resources |
| --- | --- | --- | --- | --- | --- | --- | --- | --- | --- |
|  | 2 | **Installation** |  | 2024-08-15 | 2024-09-03 |  |  |  |  |
| FJ90.3.6.2.2.1 |  | Scaffolding | 2d | 2024-08-15 | 2024-08-17 | FJ90.3.6.2.1.3 | 2d | 0d | Scaffolding Team [18 h] |
| FJ90.3.6.2.2.2 |  | Assembly | 7d | 2024-08-18 | 2024-08-24 | FJ90.3.6.2.2.1 | 2d | 0d | Fitter [72 h]; Helper [72 h] |
| FJ90.3.6.2.2.3 |  | Welding | 8d | 2024-08-24 | 2024-09-01 | FJ90.3.6.2.2.2 | 2d | 0d | Welder [72 h]; Helper [72 h] |
| FJ90.3.6.2.2.4 |  | NDT/QC | 2d | 2024-09-01 | 2024-09-03 | FJ90.3.6.2.2.3 | 2d | 0d | QC [18 h] |
|  | 7 | **Buoyancy Tank** |  | 2024-07-06 | 2024-09-22 |  |  |  |  |
|  | 1 | **B Tank Structure** |  | 2024-07-06 | 2024-09-22 |  |  |  |  |
|  | 1 | **Fabrication** |  | 2024-07-06 | 2024-07-31 |  |  |  |  |
| FJ90.3.7.1.1.2 |  | Grinding | 6d | 2024-07-06 | 2024-07-11 | FJ90.2.1 SS | 0.44d | 0d | Grinder [72 h] |
| FJ90.3.7.1.1.1 |  | Scaffolding | 2d | 2024-07-11 | 2024-07-13 | FJ90.3.7.1.1.2 | 0.44d | 0d | Scaffolding Team [18 h] |
| FJ90.3.7.1.1.3 |  | Assembly | 7d | 2024-07-13 | 2024-07-21 | FJ90.3.7.1.1.1 | 0.44d | 0d | Fitter [54 h]; Helper [54 h] |
| FJ90.3.7.1.1.4 |  | Welding | 8d | 2024-07-21 | 2024-07-28 | FJ90.3.7.1.1.3 | 0.44d | 0d | Welder [72 h]; Helper [72 h] |
| FJ90.3.7.1.1.5 |  | NDT/QC | 2d | 2024-07-28 | 2024-07-30 | FJ90.3.7.1.1.4 | 0.44d | 0d | QC [18 h] |
| FJ90.3.7.1.1.6 |  | Floating Test | 1d | 2024-07-30 | 2024-07-31 | FJ90.3.7.1.1.5 | 0.44d | 0d | QC [9 h] |
|  | 2 | **Installation** |  | 2024-09-10 | 2024-09-22 |  |  |  |  |
| FJ90.3.7.1.2.1 |  | Scaffolding | 2d | 2024-09-10 | 2024-09-11 | FJ90.3.7.1.1.6, FJ90.3.7.2.2.4, FJ90.1.3.5, FJ90.3.22.2.4, FJ90.3.20.2.4 | 0.11d | 0d | Scaffolding Team [18 h] |
| FJ90.3.7.1.2.2 |  | Assembly | 4.44d | 2024-09-12 | 2024-09-16 | FJ90.3.7.1.1.5, FJ90.3.7.1.2.1 | 0.11d | 0d | Fitter [40 h]; Helper [40 h] |
| FJ90.3.7.1.2.3 |  | Welding | 4.44d | 2024-09-16 | 2024-09-20 | FJ90.3.7.1.2.2 | 0.11d | 0d | Welder [40 h]; Helper [40 h] |
| FJ90.3.7.1.2.4 |  | NDT/QC | 2d | 2024-09-20 | 2024-09-22 | FJ90.3.7.1.2.3 | 0.11d |  | QC [18 h] |
|  | 2 | **B Tank Supports** |  | 2024-07-31 | 2024-08-24 |  |  |  |  |
|  | 1 | **Fabrication** |  | 2024-07-31 | 2024-08-11 |  |  |  |  |
| FJ90.3.7.2.1.1 |  | Assembly | 4.44d | 2024-07-31 | 2024-08-04 | FJ90.3.7.1.1.6 | 18.22d | 0d | Fitter [40 h]; Helper [40 h] |
| FJ90.3.7.2.1.2 |  | Welding | 5d | 2024-08-05 | 2024-08-09 | FJ90.3.7.2.1.1 | 18.22d | 0d | Welder [40 h]; Helper [40 h] |
| FJ90.3.7.2.1.3 |  | NDT/QC | 2d | 2024-08-09 | 2024-08-11 | FJ90.3.7.2.1.2 | 18.22d | 0d | QC [18 h] |

| ID | WBS | Activity | Duration | Start | Finish | Predecessors | Total float | Free float | Resources |
| --- | --- | --- | --- | --- | --- | --- | --- | --- | --- |
|  | 2 | **Installation** |  | 2024-08-11 | 2024-08-24 |  |  |  |  |
| FJ90.3.7.2.2.1 |  | Scaffolding | 2d | 2024-08-11 | 2024-08-13 | FJ90.3.7.2.1.3 | 18.22d | 0d | Scaffolding Team [18 h] |
| FJ90.3.7.2.2.2 |  | Assembly | 4.44d | 2024-08-13 | 2024-08-17 | FJ90.3.7.2.2.1 | 18.22d | 0d | Fitter [40 h]; Helper [40 h] |
| FJ90.3.7.2.2.3 |  | Welding | 4.44d | 2024-08-17 | 2024-08-21 | FJ90.3.7.2.2.2 | 18.22d | 0d | Welder [40 h]; Helper [40 h] |
| FJ90.3.7.2.2.4 |  | NDT/QC | 2d | 2024-08-21 | 2024-08-24 | FJ90.3.7.2.2.3 | 18.22d | 18.11d | QC [18 h] |
|  | 8 | **Caisson** |  | 2024-07-31 | 2024-09-03 |  |  |  |  |
|  | 1 | **Fabrication** |  | 2024-07-31 | 2024-08-08 |  |  |  |  |
| FJ90.3.8.1.1 |  | Assembly | 3d | 2024-07-31 | 2024-08-03 | FJ90.3.7.1.1.6 | 0.44d | 0d | Fitter [18 h]; Helper [18 h] |
| FJ90.3.8.1.2 |  | Welding | 4d | 2024-08-03 | 2024-08-07 | FJ90.3.8.1.1 | 0.44d | 0d | Welder [27 h]; Helper [27 h] |
| FJ90.3.8.1.3 |  | NDT/QC | 1d | 2024-08-07 | 2024-08-08 | FJ90.3.8.1.2 | 1.22d | 0d | QC [18 h] |
|  | 2 | **Installation** |  | 2024-08-22 | 2024-09-03 |  |  |  |  |
| FJ90.3.8.2.1 |  | Scaffolding | 2d | 2024-08-22 | 2024-08-24 | FJ90.3.8.1.3, FJ90.1.3.2, FJ90.3.13.2.5, FJ90.3.18.1.4, FJ90.3.19.1.4 | 0d |  | Scaffolding Team [18 h] |
| FJ90.3.8.2.2 |  | Assembly | 4d | 2024-08-24 | 2024-08-27 | FJ90.3.8.2.1 | 0d |  | Fitter [18 h]; Helper [18 h] |
| FJ90.3.8.2.3 |  | Welding | 5d | 2024-08-27 | 2024-09-01 | FJ90.3.8.2.2 | 0d |  | Welder [27 h]; Helper [27 h] |
| FJ90.3.8.2.4 |  | NDT/QC | 2d | 2024-09-01 | 2024-09-03 | FJ90.3.8.2.3 | 0d |  | QC [18 h] |
|  | 9 | **Crown Shim Plate** |  | 2024-09-08 | 2024-09-17 |  |  |  |  |
| FJ90.3.9.1 |  | Cutting | 5d | 2024-09-08 | 2024-09-13 | FJ90.1.3.3, FJ90.3.5.2.2.3, FJ90.3.6.1.2 | 0d |  | Cutter [45 h] |
| FJ90.3.9.2 |  | Installation | 4.44d | 2024-09-13 | 2024-09-17 | FJ90.3.9.1 | 0d |  | Fitter [40 h]; Helper [40 h] |
|  | 10 | **Flooding System** |  | 2024-08-08 | 2024-08-29 |  |  |  |  |
|  | 1 | **Fabrication** |  | 2024-08-08 | 2024-08-18 |  |  |  |  |
| FJ90.3.10.1.1 |  | Assembly | 4.44d | 2024-08-08 | 2024-08-12 | FJ90.3.8.1.3, FJ90.3.5.2.1.3 | 1.22d | 0d | Fitter [40 h]; Helper [40 h] |
| FJ90.3.10.1.2 |  | Welding | 4.44d | 2024-08-12 | 2024-08-16 | FJ90.3.10.1.1 | 1.22d | 0d | Welder [40 h]; Helper [40 h] |
| FJ90.3.10.1.3 |  | NDT/QC | 2d | 2024-08-17 | 2024-08-18 | FJ90.3.10.1.2 | 1.22d | 0d | QC [18 h] |
|  | 2 | **Installation** |  | 2024-08-18 | 2024-08-29 |  |  |  |  |
| FJ90.3.10.2.1 |  | Scaffolding | 2d | 2024-08-18 | 2024-08-20 | FJ90.1.3.4, FJ90.3.10.1.3 | 1.22d | 0d | Scaffolding Team [18 h] |
| FJ90.3.10.2.2 |  | Assembly | 3d | 2024-08-20 | 2024-08-23 | FJ90.3.10.1.3, FJ90.3.10.2.1 | 1.22d | 0d | Fitter [27 h]; Helper [27 h] |
| FJ90.3.10.2.3 |  | Welding | 4d | 2024-08-23 | 2024-08-27 | FJ90.3.10.2.2 | 1.22d | 0d | Welder [36 h]; Helper [36 h] |
| FJ90.3.10.2.4 |  | NDT/QC | 2d | 2024-08-27 | 2024-08-29 | FJ90.3.10.2.3 | 1.22d | 0d | QC [18 h] |

| ID | WBS | Activity | Duration | Start | Finish | Predecessors | Total float | Free float | Resources |
| --- | --- | --- | --- | --- | --- | --- | --- | --- | --- |
|  | 11 | **J-Tube** |  | 2024-07-24 | 2024-09-22 |  |  |  |  |
|  | 1 | **JT Structure** |  | 2024-07-28 | 2024-09-22 |  |  |  |  |
|  | 1 | **Fabrication** |  | 2024-07-28 | 2024-08-10 |  |  |  |  |
| FJ90.3.11.1.1.1 |  | Assembly | 4d | 2024-07-28 | 2024-08-01 | FJ90.3.11.2.1.3 | 5.44d | 0d | Fitter [45 h]; Helper [45 h] |
| FJ90.3.11.1.1.2 |  | Welding | 7d | 2024-08-01 | 2024-08-08 | FJ90.3.11.1.1.1 | 28.44d | 0d | Welder [63 h]; Helper [63 h] |
| FJ90.3.11.1.1.3 |  | NDT/QC | 2d | 2024-08-08 | 2024-08-10 | FJ90.3.11.1.1.2 | 28.44d |  | QC [18 h] |
|  | 2 | **Installation** |  | 2024-09-06 | 2024-09-22 |  |  |  |  |
| FJ90.3.11.1.2.1 |  | Scaffolding | 2d | 2024-09-06 | 2024-09-08 | FJ90.3.11.1.1.3, FJ90.3.11.2.2.4, FJ90.3.3.3.5 | 0d |  | Scaffolding Team [18 h] |
| FJ90.3.11.1.2.2 |  | Assembly | 6d | 2024-09-08 | 2024-09-14 | FJ90.3.11.1.2.1, FJ90.3.11.2.2.4, FJ90.3.13.2.5 | 0d |  | Fitter [90 h]; Helper [90 h] |
| FJ90.3.11.1.2.3 |  | Welding | 7d | 2024-09-14 | 2024-09-20 | FJ90.3.11.1.2.2 | 0d |  | Welder [90 h]; Helper [90 h] |
| FJ90.3.11.1.2.4 |  | NDT/QC | 2d | 2024-09-20 | 2024-09-22 | FJ90.3.11.1.2.3 | 0d |  | QC [18 h] |
|  | 2 | **JT Supports** |  | 2024-07-24 | 2024-09-06 |  |  |  |  |
|  | 1 | **Fabrication** |  | 2024-07-24 | 2024-07-28 |  |  |  |  |
| FJ90.3.11.2.1.1 |  | Assembly | 2d | 2024-07-24 | 2024-07-25 | FJ90.3.4.1.3 | 5.44d | 0d | Fitter [18 h]; Helper [18 h] |
| FJ90.3.11.2.1.2 |  | Welding | 2d | 2024-07-25 | 2024-07-27 | FJ90.3.11.2.1.1 | 5.44d | 0d | Welder [18 h]; Helper [18 h] |
| FJ90.3.11.2.1.3 |  | NDT/QC | 1d | 2024-07-28 | 2024-07-28 | FJ90.3.11.2.1.2 | 5.44d | 0d | QC [9 h] |
|  | 2 | **Installation** |  | 2024-08-22 | 2024-09-06 |  |  |  |  |
| FJ90.3.11.2.2.1 |  | Scaffolding | 2d | 2024-08-22 | 2024-08-24 | FJ90.3.11.2.1.3, FJ90.3.13.2.5, FJ90.3.18.1.4, FJ90.3.19.1.4 | 0d |  | Scaffolding Team [18 h] |
| FJ90.3.11.2.2.2 |  | Assembly | 6d | 2024-08-24 | 2024-08-29 | FJ90.3.11.2.2.1 | 0d |  | Fitter [54 h]; Helper [54 h] |
| FJ90.3.11.2.2.3 |  | Welding | 6d | 2024-08-29 | 2024-09-04 | FJ90.3.11.2.2.2 | 0d |  | Welder [72 h]; Helper [72 h] |
| FJ90.3.11.2.2.4 |  | NDT/QC | 2d | 2024-09-04 | 2024-09-06 | FJ90.3.11.2.2.3 | 0d |  | QC [18 h] |
|  | 12 | **Leg Arrangement** |  | 2024-08-29 | 2024-09-10 |  |  |  |  |
|  | 1 | **Installation** |  | 2024-08-29 | 2024-09-10 |  |  |  |  |
| FJ90.3.12.1.1 |  | Scaffolding | 2d | 2024-08-29 | 2024-08-31 | FJ90.3.10.2.4 | 1.22d | 0d | Scaffolding Team [18 h] |
| FJ90.3.12.1.2 |  | Assembly | 4.44d | 2024-08-31 | 2024-09-04 | FJ90.3.12.1.1 | 1.22d | 0d | Fitter [40 h]; Helper [40 h] |
| FJ90.3.12.1.3 |  | Welding | 4.44d | 2024-09-04 | 2024-09-08 | FJ90.3.12.1.2 | 1.22d | 0d | Welder [40 h]; Helper [40 h] |
| FJ90.3.12.1.4 |  | NDT/QC | 2d | 2024-09-08 | 2024-09-10 | FJ90.3.12.1.3 | 1.22d | 0d | QC [18 h] |

| ID | WBS | Activity | Duration | Start | Finish | Predecessors | Total float | Free float | Resources |
| --- | --- | --- | --- | --- | --- | --- | --- | --- | --- |
|  | 13 | **Level 1-FXA** |  | 2024-07-24 | 2024-08-10 |  |  |  |  |
|  | 2 | **Installation** |  | 2024-07-24 | 2024-08-10 |  |  |  |  |
| FJ90.3.13.2.1 |  | Sandblasting & Painting | 3d | 2024-07-24 | 2024-07-27 | FJ90.3.4.1.3 | 0d |  | Painting Team [63 h] |
| FJ90.3.13.2.2 |  | Scaffolding | 2d | 2024-07-27 | 2024-07-28 | FJ90.3.13.2.1 | 0d |  | Scaffolding Team [18 h] |
| FJ90.3.13.2.3 |  | Assembly | 4.44d | 2024-07-28 | 2024-08-01 | FJ90.3.13.2.2 | 0d |  | Fitter [144 h]; Helper [144 h] |
| FJ90.3.13.2.4 |  | Welding | 7d | 2024-08-01 | 2024-08-08 | FJ90.3.13.2.3 | 0d |  | Welder [180 h]; Helper [90 h] |
| FJ90.3.13.2.5 |  | NDT/QC | 2d | 2024-08-08 | 2024-08-10 | FJ90.3.13.2.4 | 12d |  | QC [18 h] |
|  | 14 | **Lifting Pad Eye** |  | 2024-09-03 | 2024-09-10 |  |  |  |  |
|  | 3 | **Installation** |  | 2024-09-03 | 2024-09-10 |  |  |  |  |
| FJ90.3.14.3.1 |  | Scaffolding | 2d | 2024-09-03 | 2024-09-05 | FJ90.3.3.3.5 | 0d |  | Scaffolding Team [18 h] |
| FJ90.3.14.3.2 |  | Assembly | 2d | 2024-09-05 | 2024-09-07 | FJ90.3.14.3.1 | 13d | 0d | Fitter [18 h]; Helper [18 h] |
| FJ90.3.14.3.3 |  | Welding | 2d | 2024-09-07 | 2024-09-09 | FJ90.3.14.3.2 | 13d | 0d | Welder [18 h]; Helper [18 h] |
| FJ90.3.14.3.4 |  | NDT/QC | 1d | 2024-09-09 | 2024-09-10 | FJ90.3.14.3.3 | 13d |  | QC [9 h] |
|  | 15 | **Mud Mat** |  | 2024-09-05 | 2024-09-20 |  |  |  |  |
|  | 1 | **Installation** |  | 2024-09-05 | 2024-09-20 |  |  |  |  |
| FJ90.3.15.1.1 |  | Scaffolding | 2d | 2024-09-05 | 2024-09-07 | FJ90.3.18.1.4, FJ90.3.19.1.3, FJ90.3.13.2.5, FJ90.3.14.3.1 | 0d |  | Scaffolding Team [18 h] |
| FJ90.3.15.1.2 |  | Assembly | 4d | 2024-09-07 | 2024-09-11 | FJ90.3.15.1.1 | 2d | 0d | Fitter [36 h]; Helper [36 h] |
| FJ90.3.15.1.3 |  | Welding | 8d | 2024-09-11 | 2024-09-18 | FJ90.3.15.1.2 | 2d | 0d | Welder [72 h]; Helper [72 h] |
| FJ90.3.15.1.4 |  | NDT/QC | 2d | 2024-09-18 | 2024-09-20 | FJ90.3.15.1.3 | 2d |  | QC [18 h] |
|  | 18 | **Row A** |  | 2024-08-08 | 2024-08-21 |  |  |  |  |
|  | 1 | **Installation** |  | 2024-08-08 | 2024-08-21 |  |  |  |  |
| FJ90.3.18.1.1 |  | Scaffolding | 2d | 2024-08-08 | 2024-08-10 | FJ90.3.13.2.4 | 0d |  | Scaffolding Team [18 h] |
| FJ90.3.18.1.2 |  | Assembly | 5d | 2024-08-10 | 2024-08-15 | FJ90.3.18.1.1 | 0d |  | Fitter [90 h]; Helper [90 h] |
| FJ90.3.18.1.3 |  | Welding | 5d | 2024-08-15 | 2024-08-20 | FJ90.3.18.1.2 | 0d |  | Welder [144 h]; Helper [72 h] |
| FJ90.3.18.1.4 |  | NDT/QC | 2d | 2024-08-20 | 2024-08-21 | FJ90.3.18.1.3 | 0d |  | QC [18 h] |

| ID | WBS | Activity | Duration | Start | Finish | Predecessors | Total float | Free float | Resources |
| --- | --- | --- | --- | --- | --- | --- | --- | --- | --- |
|  | 19 | **Row B** |  | 2024-08-08 | 2024-08-21 |  |  |  |  |
|  | 1 | **Installation** |  | 2024-08-08 | 2024-08-21 |  |  |  |  |
| FJ90.3.19.1.1 |  | Scaffolding | 2d | 2024-08-08 | 2024-08-10 | FJ90.3.18.1.1 SS | 0d |  | Scaffolding Team [18 h] |
| FJ90.3.19.1.2 |  | Assembly | 5d | 2024-08-10 | 2024-08-15 | FJ90.3.19.1.1 | 0d |  | Fitter [90 h]; Helper [90 h] |
| FJ90.3.19.1.3 |  | Welding | 5d | 2024-08-15 | 2024-08-20 | FJ90.3.19.1.2 | 0d |  | Welder [144 h]; Helper [72 h] |
| FJ90.3.19.1.4 |  | NDT/QC | 2d | 2024-08-20 | 2024-08-21 | FJ90.3.19.1.3 | 0d |  | QC [18 h] |
|  | 20 | **Stabbing Cone** |  | 2024-08-07 | 2024-08-29 |  |  |  |  |
|  | 1 | **Fabrication** |  | 2024-08-07 | 2024-08-17 |  |  |  |  |
| FJ90.3.20.1.1 |  | Assembly | 3d | 2024-08-07 | 2024-08-10 | FJ90.3.8.1.2 | 0.44d | 0d | Fitter [27 h]; Helper [27 h] |
| FJ90.3.20.1.2 |  | Welding | 5d | 2024-08-10 | 2024-08-14 | FJ90.3.20.1.1 | 0.44d | 0d | Welder [54 h]; Helper [54 h] |
| FJ90.3.20.1.3 |  | NDT/Qc | 2d | 2024-08-14 | 2024-08-17 | FJ90.3.20.1.2 | 0.44d | 0d | QC [9 h] |
|  | 2 | **Installation** |  | 2024-08-17 | 2024-08-29 |  |  |  |  |
| FJ90.3.20.2.1 |  | Scaffolding | 2d | 2024-08-17 | 2024-08-18 | FJ90.3.20.1.3 | 0.44d | 0d | Scaffolding Team [18 h] |
| FJ90.3.20.2.2 |  | Assembly | 4d | 2024-08-18 | 2024-08-22 | FJ90.3.20.2.1 | 0.44d | 0d | Fitter [36 h]; Helper [36 h] |
| FJ90.3.20.2.3 |  | Welding | 5d | 2024-08-22 | 2024-08-27 | FJ90.3.20.2.2 | 0.44d | 0d | Welder [72 h]; Helper [72 h] |
| FJ90.3.20.2.4 |  | NDT/QC | 2d | 2024-08-27 | 2024-08-29 | FJ90.3.20.2.3 | 0.44d | 0d | QC [18 h] |
|  | 21 | **Rigging Platform** |  | 2024-08-27 | 2024-09-14 |  |  |  |  |
|  | 1 | **Fabrication** |  | 2024-08-27 | 2024-09-11 |  |  |  |  |
| FJ90.3.21.1.1 |  | Assembly | 7d | 2024-08-27 | 2024-09-03 | FJ90.3.3.3.2 | 2d | 0d | Fitter [63 h]; Helper [63 h] |
| FJ90.3.21.1.2 |  | Welding | 7d | 2024-09-03 | 2024-09-10 | FJ90.3.21.1.1 | 4d | 0d | Welder [63 h]; Helper [63 h] |
| FJ90.3.21.1.3 |  | NDT/QC | 2d | 2024-09-10 | 2024-09-11 | FJ90.3.21.1.2 | 4d | 0d | QC [18 h] |
|  | 2 | **Installation** |  | 2024-09-12 | 2024-09-14 |  |  |  |  |
| FJ90.3.21.2.1 |  | Trial | 2d | 2024-09-12 | 2024-09-14 | FJ90.3.21.1.3, FJ90.3.5.2.2.3 | 4d |  | Fitter [18 h]; Helper [18 h]; QC [18 h] |
|  | 22 | **Upending Pad eye** |  | 2024-09-03 | 2024-09-10 |  |  |  |  |
|  | 2 | **Installation** |  | 2024-09-03 | 2024-09-10 |  |  |  |  |
| FJ90.3.22.2.1 |  | Scaffolding | 2d | 2024-09-03 | 2024-09-05 | FJ90.3.3.3.5 | 0.11d | 0d | Scaffolding Team [18 h] |
| FJ90.3.22.2.2 |  | Assembly | 2d | 2024-09-05 | 2024-09-07 | FJ90.3.22.2.1 | 0.11d | 0d | Fitter [18 h]; Helper [18 h] |
| FJ90.3.22.2.3 |  | Welding | 2d | 2024-09-07 | 2024-09-09 | FJ90.3.22.2.2 | 0.11d | 0d | Welder [18 h]; Helper [18 h] |
| FJ90.3.22.2.4 |  | NDT/QC | 1d | 2024-09-09 | 2024-09-10 | FJ90.3.22.2.3 | 0.11d | 0d | QC [9 h] |

| ID | WBS | Activity | Duration | Start | Finish | Predecessors | Total float | Free float | Resources |
| --- | --- | --- | --- | --- | --- | --- | --- | --- | --- |
|  | 23 | **Pile Make up** |  | 2024-09-17 | 2024-09-22 |  |  |  |  |
|  | 1 | **Fabrication** |  | 2024-09-17 | 2024-09-22 |  |  |  |  |
| FJ90.3.23.1.1 |  | Assembly | 2d | 2024-09-17 | 2024-09-19 | FJ90.3.9.2, FJ90.3.21.2.1 | 0d |  | Fitter [18 h]; Helper [18 h] |
| FJ90.3.23.1.2 |  | Welding | 2d | 2024-09-19 | 2024-09-21 | FJ90.3.23.1.1 | 0d |  | Welder [18 h]; Helper [18 h] |
| FJ90.3.23.1.3 |  | NDT/QC | 1d | 2024-09-21 | 2024-09-22 | FJ90.3.23.1.2 | 0d |  | QC [9 h] |
|  | 24 | **Flooding System & Leg Air Testing** |  | 2024-09-22 | 2024-09-24 |  |  |  |  |
| FJ90.3.24.1 |  | Test | 2d | 2024-09-22 | 2024-09-24 | FJ90.3.2.1.2, FJ90.3.2.2.3, FJ90.3.3.3.5, FJ90.3.4.2.4, FJ90.3.5.2.2.3, FJ90.3.6.1.2, FJ90.3.7.1.2.4, FJ90.3.8.2.4, FJ90.3.9.2, FJ90.3.10.2.4, FJ90.3.11.1.2.4, FJ90.3.12.1.4, FJ90.3.13.2.5, FJ90.3.14.3.4, FJ90.3.15.1.4, FJ90.3.18.1.4, FJ90.3.19.1.4, FJ90.3.20.2.4, FJ90.3.21.2.1, FJ90.3.22.2.4, FJ90.3.23.1.3 | 0d |  | QC [9 h] |
|  | 4 | **F19** |  | 2024-07-06 | 2024-10-02 |  |  |  |  |
|  | 1 | **Paint** |  | 2024-09-24 | 2024-10-02 |  |  |  |  |
| FJ90.4.1.1 |  | Blasting | 4d | 2024-09-24 | 2024-09-28 | FJ90.4.24.1 | 0d |  | Painting Team |
| FJ90.4.1.2 |  | Painting | 4d | 2024-09-28 | 2024-10-02 | FJ90.4.1.1 | 0d |  | Painting Team |
|  | 2 | **Anode** |  | 2024-07-06 | 2024-08-16 |  |  |  |  |
|  | 1 | **Assembled Anode(20 PCS)** |  | 2024-07-06 | 2024-07-14 |  |  |  |  |
| FJ90.4.2.1.1 |  | welding | 8d | 2024-07-06 | 2024-07-13 | FJ90.2.1 | 49.44d | 0d | Welder [40 h]; Helper [40 h]; Welder [72 h]; Helper [72 h] |
| FJ90.4.2.1.2 |  | QC | 2d | 2024-07-12 | 2024-07-14 | FJ90.4.2.1.1 FS-1d | 58.44d | 19.56d | QC [18 h] |
|  | 2 | **New Anode Installation(35 PCS)** |  | 2024-08-03 | 2024-08-16 |  |  |  |  |
| FJ90.4.2.2.1 |  | Assembly | 6d | 2024-08-03 | 2024-08-08 | FJ90.4.2.1.2, FJ90.1.3.7 | 38.89d | 0d | Fitter [40 h]; Helper [54 h] |
| FJ90.4.2.2.2 |  | Welding | 6d | 2024-08-08 | 2024-08-14 | FJ90.4.2.2.1 | 38.89d | 0d | Welder [54 h]; Helper [54 h] |
| FJ90.4.2.2.3 |  | QC | 2d | 2024-08-14 | 2024-08-16 | FJ90.4.2.2.2 | 38.89d |  | QC [18 h] |
|  | 3 | **Riser** |  | 2024-08-20 | 2024-09-19 |  |  |  |  |
|  | 1 | **Sandblasting** |  | 2024-08-20 | 2024-08-28 |  |  |  |  |
| FJ90.4.3.1.1 |  | Sandblast | 8d | 2024-08-20 | 2024-08-28 | FJ90.3.3.2.3 | 3d | 0d | Painting Team [72 h] |
|  | 2 | **Fabrication** |  | 2024-08-28 | 2024-09-08 |  |  |  |  |
| FJ90.4.3.2.1 |  | Assembly | 4d | 2024-08-28 | 2024-09-01 | FJ90.4.3.1.1 | 3d | 0d | Fitter [27 h]; Helper [27 h] |
| FJ90.4.3.2.2 |  | Welding | 6d | 2024-09-01 | 2024-09-07 | FJ90.4.3.2.1 | 3d | 0d | Welder [45 h]; Helper [45 h] |
| FJ90.4.3.2.3 |  | NDT/QC | 2d | 2024-09-07 | 2024-09-08 | FJ90.4.3.2.2 | 3d | 0d | QC [18 h] |

| ID | WBS | Activity | Duration | Start | Finish | Predecessors | Total float | Free float | Resources |
| --- | --- | --- | --- | --- | --- | --- | --- | --- | --- |
|  | 3 | **Installation** |  | 2024-09-08 | 2024-09-19 |  |  |  |  |
| FJ90.4.3.3.1 |  | Scaffolding | 2d | 2024-09-08 | 2024-09-10 | FJ90.4.3.2.3, FJ90.1.3.1, FJ90.4.4.2.4 | 3d | 0d | Scaffolding Team [18 h] |
| FJ90.4.3.3.2 |  | Assembly | 4.44d | 2024-09-10 | 2024-09-15 | FJ90.4.3.3.1, FJ90.4.4.2.4, FJ90.3.3.3.2 | 3d | 0d | Fitter [40 h]; Helper [40 h] |
| FJ90.4.3.3.3 |  | Welding | 2d | 2024-09-15 | 2024-09-16 | FJ90.4.3.3.2 | 3d | 0d | Welder [18 h]; Helper [18 h] |
| FJ90.4.3.3.4 |  | NDT/QC | 2d | 2024-09-16 | 2024-09-18 | FJ90.4.3.3.3 | 3d | 0d | QC [18 h] |
| FJ90.4.3.3.5 |  | Hydro Test | 1d | 2024-09-18 | 2024-09-19 | FJ90.4.3.3.4 | 3d |  | QC [9 h] |
|  | 4 | **Riser Clamp** |  | 2024-08-02 | 2024-09-08 |  |  |  |  |
|  | 1 | **Fabrication** |  | 2024-08-02 | 2024-08-17 |  |  |  |  |
| FJ90.4.4.1.1 |  | Assembly | 6d | 2024-08-02 | 2024-08-08 | FJ90.3.4.2.2 | 3d | 0d | Fitter [90 h]; Helper [90 h] |
| FJ90.4.4.1.2 |  | Welding | 8d | 2024-08-08 | 2024-08-15 | FJ90.4.4.1.1 | 3d | 0d | Welder [108 h]; Helper [108 h] |
| FJ90.4.4.1.3 |  | NDT/Qc | 2d | 2024-08-15 | 2024-08-17 | FJ90.4.4.1.2 | 3d | 0d | QC [18 h] |
|  | 2 | **Installation** |  | 2024-08-18 | 2024-09-08 |  |  |  |  |
| FJ90.4.4.2.1 |  | Scaffolding | 2d | 2024-08-18 | 2024-08-19 | FJ90.4.4.1.3 | 3d | 0d | Scaffolding Team [18 h] |
| FJ90.4.4.2.2 |  | Assembly | 9d | 2024-08-19 | 2024-08-28 | FJ90.4.4.2.1, FJ90.3.4.2.2 | 3d | 0d | Fitter [90 h]; Helper [90 h] |
| FJ90.4.4.2.3 |  | Welding | 10d | 2024-08-28 | 2024-09-07 | FJ90.4.4.2.2 | 3d | 0d | Welder [90 h]; Helper [90 h] |
| FJ90.4.4.2.4 |  | NDT/QC | 2d | 2024-09-07 | 2024-09-08 | FJ90.4.4.2.3 | 3d | 0d | QC [18 h] |
|  | 5 | **Barge bumper** |  | 2024-07-28 | 2024-09-18 |  |  |  |  |
|  | 3 | **Sandblasting & Painting** |  | 2024-07-28 | 2024-08-02 |  |  |  |  |
| FJ90.4.5.3 |  | sandblasting | 6d | 2024-07-28 | 2024-08-02 | FJ90.3.5.1.1 | 4.44d | 0d |  |
|  | 1 | **BB Structure** |  | 2024-08-02 | 2024-09-18 |  |  |  |  |
|  | 1 | **Fabrication** |  | 2024-08-02 | 2024-08-10 |  |  |  |  |
| FJ90.4.5.1.1.1 |  | Assembly | 2d | 2024-08-02 | 2024-08-04 | FJ90.4.5.3 | 4.44d | 0d | Fitter [18 h]; Helper [18 h] |
| FJ90.4.5.1.1.2 |  | Welding | 4d | 2024-08-04 | 2024-08-08 | FJ90.4.5.1.1.1 | 4.44d | 0d | Welder [18 h]; Helper [18 h] |
| FJ90.4.5.1.1.3 |  | NDT/QC | 2d | 2024-08-08 | 2024-08-10 | FJ90.4.5.1.1.2 | 4.44d | 0d | QC [9 h] |

| ID | WBS | Activity | Duration | Start | Finish | Predecessors | Total float | Free float | Resources |
| --- | --- | --- | --- | --- | --- | --- | --- | --- | --- |
|  | 2 | **Installation** |  | 2024-09-13 | 2024-09-18 |  |  |  |  |
| FJ90.4.5.1.2.1 |  | Assembly | 2d | 2024-09-13 | 2024-09-15 | FJ90.4.5.1.1.3, FJ90.4.5.2.2.4 | 4.44d | 0d | Fitter [18 h]; Helper [18 h] |
| FJ90.4.5.1.2.2 |  | Welding | 2d | 2024-09-15 | 2024-09-17 | FJ90.4.5.1.2.1 | 4.44d | 0d | Welder [18 h]; Helper [18 h] |
| FJ90.4.5.1.2.3 |  | NDT/QC | 1d | 2024-09-17 | 2024-09-18 | FJ90.4.5.1.2.2 | 4.44d |  | QC [9 h] |
|  | 2 | **BB Supports** |  | 2024-08-10 | 2024-09-13 |  |  |  |  |
|  | 1 | **Fabrication** |  | 2024-08-10 | 2024-08-25 |  |  |  |  |
| FJ90.4.5.2.1.1 |  | Assembly | 6d | 2024-08-10 | 2024-08-15 | FJ90.4.5.1.1.1, FJ90.4.5.1.1.3 | 4.44d | 0d | Fitter [54 h]; Helper [54 h] |
| FJ90.4.5.2.1.2 |  | Welding | 8d | 2024-08-15 | 2024-08-23 | FJ90.4.5.2.1.1, FJ90.3.5.3.1.2 | 4.44d | 0d | Welder [72 h]; Helper [72 h] |
| FJ90.4.5.2.1.3 |  | NDT/QC | 2d | 2024-08-23 | 2024-08-25 | FJ90.4.5.2.1.2 | 4.44d | 0d | QC [18 h] |
|  | 2 | **Installation** |  | 2024-08-25 | 2024-09-13 |  |  |  |  |
| FJ90.4.5.2.2.1 |  | Scaffolding | 2d | 2024-08-25 | 2024-08-27 | FJ90.4.5.2.1.3 | 4.44d | 0d | Scaffolding Team [18 h] |
| FJ90.4.5.2.2.2 |  | Assembly | 8d | 2024-08-27 | 2024-09-03 | FJ90.4.5.2.2.1 | 4.44d | 0d | Fitter [72 h]; Helper [72 h] |
| FJ90.4.5.2.2.3 |  | Welding | 8d | 2024-09-04 | 2024-09-11 | FJ90.4.5.2.2.2 | 4.44d | 0d | Welder [72 h]; Helper [72 h] |
| FJ90.4.5.2.2.4 |  | NDT/QC | 2d | 2024-09-11 | 2024-09-13 | FJ90.4.5.2.2.3 | 4.44d | 0d | QC [18 h] |
|  | 6 | **Boat Landing** |  | 2024-07-31 | 2024-09-14 |  |  |  |  |
|  | 1 | **BL Structure** |  | 2024-07-31 | 2024-09-14 |  |  |  |  |
| FJ90.4.6.1.1 |  | Sandblasting & Painting | 4.44d | 2024-07-31 | 2024-08-04 | FJ90.3.6.1.1 | 10.56d | 1.56d | Painting Team [40 h] |
| FJ90.4.6.1.2 |  | Trial Installation | 4.44d | 2024-09-09 | 2024-09-14 | FJ90.4.6.2.2.4 | 9d |  | Fitter [40 h]; Helper [40 h]; QC [40 h] |
|  | 2 | **BL Supports** |  | 2024-08-06 | 2024-09-09 |  |  |  |  |
|  | 1 | **Fabrication** |  | 2024-08-06 | 2024-08-21 |  |  |  |  |
| FJ90.4.6.2.1.1 |  | Assembly | 6d | 2024-08-06 | 2024-08-12 | FJ90.3.6.2.1.1, FJ90.4.6.1.1 | 9d | 0d | Fitter [54 h]; Helper [54 h] |
| FJ90.4.6.2.1.2 |  | Welding | 8d | 2024-08-12 | 2024-08-19 | FJ90.4.6.2.1.1 | 9d | 0d | Welder [72 h]; Helper [72 h] |
| FJ90.4.6.2.1.3 |  | NDT/QC | 2d | 2024-08-19 | 2024-08-21 | FJ90.4.6.2.1.2 | 9d | 0d | QC [18 h] |
|  | 2 | **Installation** |  | 2024-08-21 | 2024-09-09 |  |  |  |  |
| FJ90.4.6.2.2.1 |  | Scaffolding | 2d | 2024-08-21 | 2024-08-23 | FJ90.4.6.2.1.3, FJ90.3.6.2.2.1 | 9d | 0d | Scaffolding Team [18 h] |
| FJ90.4.6.2.2.2 |  | Assembly | 8d | 2024-08-23 | 2024-08-31 | FJ90.4.6.2.2.1 | 9d | 0d | Fitter [72 h]; Helper [72 h] |
| FJ90.4.6.2.2.3 |  | Welding | 8d | 2024-08-31 | 2024-09-07 | FJ90.4.6.2.2.2 | 9d | 0d | Welder [72 h]; Helper [72 h] |
| FJ90.4.6.2.2.4 |  | NDT/QC | 2d | 2024-09-08 | 2024-09-09 | FJ90.4.6.2.2.3 | 9d | 0d | QC [18 h] |

| ID | WBS | Activity | Duration | Start | Finish | Predecessors | Total float | Free float | Resources |
| --- | --- | --- | --- | --- | --- | --- | --- | --- | --- |
|  | 7 | **Buoyancy Tank** |  | 2024-07-11 | 2024-09-09 |  |  |  |  |
|  | 1 | **B Tank Structure** |  | 2024-07-11 | 2024-09-09 |  |  |  |  |
|  | 1 | **Fabrication** |  | 2024-07-11 | 2024-08-05 |  |  |  |  |
| FJ90.4.7.1.1.1 |  | Grinding | 6d | 2024-07-11 | 2024-07-18 | FJ90.3.7.1.1.2 | 0.78d | 0d | Grinder [72 h] |
| FJ90.4.7.1.1.2 |  | Scaffolding | 2d | 2024-07-18 | 2024-07-20 | FJ90.4.7.1.1.1 | 0.78d | 0d | Scaffolding Team [18 h] |
| FJ90.4.7.1.1.3 |  | Assembly | 7d | 2024-07-20 | 2024-07-27 | FJ90.4.7.1.1.2 | 0.78d | 0d | Fitter [54 h]; Helper [54 h] |
| FJ90.4.7.1.1.4 |  | Welding | 7d | 2024-07-27 | 2024-08-02 | FJ90.4.7.1.1.3 | 0.78d | 0d | Welder [72 h]; Helper [72 h] |
| FJ90.4.7.1.1.5 |  | NDT/QC | 2d | 2024-08-02 | 2024-08-04 | FJ90.4.7.1.1.4 | 0.78d | 0d | QC [18 h] |
| FJ90.4.7.1.1.6 |  | Floating Test | 1d | 2024-08-04 | 2024-08-05 | FJ90.4.7.1.1.5 | 0.78d | 0d | QC [9 h] |
|  | 2 | **Installation** |  | 2024-08-28 | 2024-09-09 |  |  |  |  |
| FJ90.4.7.1.2.1 |  | Scaffolding | 2d | 2024-08-28 | 2024-08-30 | FJ90.4.7.1.1.6, FJ90.4.7.2.2.4, FJ90.1.3.5 | 0.78d | 0d | Scaffolding Team [18 h] |
| FJ90.4.7.1.2.2 |  | Assembly | 4.44d | 2024-08-30 | 2024-09-03 | FJ90.4.7.1.1.5, FJ90.4.7.1.2.1 | 0.78d | 0d | Fitter [40 h]; Helper [40 h] |
| FJ90.4.7.1.2.3 |  | Welding | 4d | 2024-09-03 | 2024-09-07 | FJ90.4.7.1.2.2 | 0.78d | 0d | Welder [40 h]; Helper [40 h] |
| FJ90.4.7.1.2.4 |  | NDT/QC | 2d | 2024-09-07 | 2024-09-09 | FJ90.4.7.1.2.3 | 0.78d | 0d | QC [18 h] |
|  | 2 | **B Tank Supports** |  | 2024-08-05 | 2024-08-28 |  |  |  |  |
|  | 1 | **Fabrication** |  | 2024-08-05 | 2024-08-16 |  |  |  |  |
| FJ90.4.7.2.1.1 |  | Assembly | 4.44d | 2024-08-05 | 2024-08-09 | FJ90.4.7.1.1.1 SS, FJ90.4.7.1.1.6 | 0.78d | 0d | Fitter [40 h]; Helper [40 h] |
| FJ90.4.7.2.1.2 |  | Welding | 5d | 2024-08-09 | 2024-08-14 | FJ90.4.7.2.1.1 | 0.78d | 0d | Welder [40 h]; Helper [40 h] |
| FJ90.4.7.2.1.3 |  | NDT/QC | 2d | 2024-08-14 | 2024-08-16 | FJ90.4.7.2.1.2 | 0.78d | 0d | QC [18 h] |
|  | 2 | **Installation** |  | 2024-08-16 | 2024-08-28 |  |  |  |  |
| FJ90.4.7.2.2.1 |  | Scaffolding | 2d | 2024-08-16 | 2024-08-18 | FJ90.4.7.2.1.3 | 0.78d | 0d | Scaffolding Team [18 h] |
| FJ90.4.7.2.2.2 |  | Assembly | 4.44d | 2024-08-18 | 2024-08-22 | FJ90.4.7.2.2.1 | 0.78d | 0d | Fitter [40 h]; Helper [40 h] |
| FJ90.4.7.2.2.3 |  | Welding | 4.44d | 2024-08-22 | 2024-08-26 | FJ90.4.7.2.2.2 | 0.78d | 0d | Welder [40 h]; Helper [40 h] |
| FJ90.4.7.2.2.4 |  | NDT/QC | 2d | 2024-08-26 | 2024-08-28 | FJ90.4.7.2.2.3 | 0.78d | 0d | QC [18 h] |

| ID | WBS | Activity | Duration | Start | Finish | Predecessors | Total float | Free float | Resources |
| --- | --- | --- | --- | --- | --- | --- | --- | --- | --- |
|  | 8 | **Caisson** |  | 2024-09-03 | 2024-09-22 |  |  |  |  |
|  | 1 | **Fabrication** |  | 2024-09-03 | 2024-09-11 |  |  |  |  |
| FJ90.4.8.1.1 |  | Assembly | 3d | 2024-09-03 | 2024-09-06 | FJ90.3.8.2.4 | 0d |  | Fitter [18 h]; Helper [18 h] |
| FJ90.4.8.1.2 |  | Welding | 4d | 2024-09-06 | 2024-09-10 | FJ90.4.8.1.1 | 0d |  | Welder [27 h]; Helper [27 h] |
| FJ90.4.8.1.3 |  | NDT/QC | 1d | 2024-09-10 | 2024-09-11 | FJ90.4.8.1.2 | 0d |  | QC [18 h] |
|  | 2 | **Installation** |  | 2024-09-11 | 2024-09-22 |  |  |  |  |
| FJ90.4.8.2.1 |  | Scaffolding | 2d | 2024-09-11 | 2024-09-12 | FJ90.1.3.2, FJ90.3.8.2.1, FJ90.4.8.1.3 | 0d |  | Scaffolding Team [18 h] |
| FJ90.4.8.2.2 |  | Assembly | 4d | 2024-09-12 | 2024-09-16 | FJ90.4.8.1.3, FJ90.4.8.2.1 | 0d |  | Fitter [18 h]; Helper [18 h] |
| FJ90.4.8.2.3 |  | Welding | 4d | 2024-09-16 | 2024-09-20 | FJ90.4.8.2.2 | 0d |  | Welder [27 h]; Helper [27 h] |
| FJ90.4.8.2.4 |  | NDT/QC | 2d | 2024-09-20 | 2024-09-22 | FJ90.4.8.2.3 | 0d |  | QC [18 h] |
|  | 9 | **Crown Shim Plate** |  | 2024-09-13 | 2024-09-22 |  |  |  |  |
| FJ90.4.9.1 |  | Cutting | 5d | 2024-09-13 | 2024-09-18 | FJ90.1.3.3 SS, FJ90.3.9.1 | 0d |  | Cutter [45 h] |
| FJ90.4.9.2 |  | Installation | 4.44d | 2024-09-18 | 2024-09-22 | FJ90.4.9.1 | 0d |  | Fitter [40 h]; Helper [40 h] |
|  | 10 | **Flooding System** |  | 2024-08-29 | 2024-09-18 |  |  |  |  |
|  | 1 | **Fabrication** |  | 2024-08-29 | 2024-09-08 |  |  |  |  |
| FJ90.4.10.1.1 |  | Assembly | 4.44d | 2024-08-29 | 2024-09-02 | FJ90.3.10.2.4 | 3.67d | 0d | Fitter [40 h]; Helper [40 h] |
| FJ90.4.10.1.2 |  | Welding | 4.44d | 2024-09-02 | 2024-09-06 | FJ90.4.10.1.1 | 3.67d | 0d | Welder [40 h]; Helper [40 h] |
| FJ90.4.10.1.3 |  | NDT/QC | 2d | 2024-09-06 | 2024-09-08 | FJ90.4.10.1.2 | 3.67d | 0d | QC [18 h] |
|  | 2 | **Installation** |  | 2024-09-08 | 2024-09-18 |  |  |  |  |
| FJ90.4.10.2.1 |  | Scaffolding | 2d | 2024-09-08 | 2024-09-10 | FJ90.1.3.4, FJ90.4.10.1.3 | 3.67d | 0d | Scaffolding Team [18 h] |
| FJ90.4.10.2.2 |  | Assembly | 3d | 2024-09-10 | 2024-09-13 | FJ90.4.10.1.3, FJ90.4.10.2.1 | 3.67d | 0d | Fitter [27 h]; Helper [27 h] |
| FJ90.4.10.2.3 |  | Welding | 4d | 2024-09-13 | 2024-09-17 | FJ90.4.10.2.2 | 3.67d | 0d | Welder [36 h]; Helper [36 h] |
| FJ90.4.10.2.4 |  | NDT/QC | 2d | 2024-09-17 | 2024-09-18 | FJ90.4.10.2.3 | 3.67d |  | QC [18 h] |
|  | 11 | **J-Tube** |  | 2024-08-01 | 2024-09-17 |  |  |  |  |
|  | 1 | **JT Structure** |  | 2024-08-06 | 2024-09-17 |  |  |  |  |
|  | 1 | **Fabrication** |  | 2024-08-06 | 2024-08-18 |  |  |  |  |
| FJ90.4.11.1.1.1 |  | Assembly | 4d | 2024-08-06 | 2024-08-10 | FJ90.4.11.2.1.3 | 5.44d | 0d | Fitter [45 h]; Helper [45 h] |
| FJ90.4.11.1.1.2 |  | Welding | 7d | 2024-08-10 | 2024-08-17 | FJ90.4.11.1.1.1 | 5.44d | 0d |  |
| FJ90.4.11.1.1.3 |  | NDT/QC | 2d | 2024-08-17 | 2024-08-18 | FJ90.4.11.1.1.2 | 5.44d | 0d | QC [18 h] |

| ID | WBS | Activity | Duration | Start | Finish | Predecessors | Total float | Free float | Resources |
| --- | --- | --- | --- | --- | --- | --- | --- | --- | --- |
|  | 2 | **Installation** |  | 2024-09-03 | 2024-09-17 |  |  |  |  |
| FJ90.4.11.1.2.2 |  | Assembly | 6d | 2024-09-03 | 2024-09-08 | FJ90.4.11.2.2.4 | 5.44d | 0d | Fitter [90 h]; Helper [90 h] |
| FJ90.4.11.1.2.1 |  | Scaffolding | 2d | 2024-09-06 | 2024-09-08 | FJ90.4.11.1.1.3, FJ90.4.11.2.2.4, FJ90.3.11.1.2.1 SS | 25d |  | Scaffolding Team [18 h] |
| FJ90.4.11.1.2.3 |  | Welding | 7d | 2024-09-08 | 2024-09-15 | FJ90.4.11.1.2.2 | 5.44d | 0d | Welder [90 h]; Helper [90 h] |
| FJ90.4.11.1.2.4 |  | NDT/QC | 2d | 2024-09-15 | 2024-09-17 | FJ90.4.11.1.2.3 | 5.44d |  | QC [18 h] |
|  | 2 | **JT Supports** |  | 2024-08-01 | 2024-09-03 |  |  |  |  |
|  | 1 | **Fabrication** |  | 2024-08-01 | 2024-08-06 |  |  |  |  |
| FJ90.4.11.2.1.1 |  | Assembly | 2d | 2024-08-01 | 2024-08-03 | FJ90.3.11.1.1.1 | 5.44d | 0d | Fitter [18 h]; Helper [18 h] |
| FJ90.4.11.2.1.2 |  | Welding | 2d | 2024-08-03 | 2024-08-05 | FJ90.4.11.2.1.1 | 5.44d | 0d | Welder [18 h]; Helper [18 h] |
| FJ90.4.11.2.1.3 |  | NDT/QC | 1d | 2024-08-05 | 2024-08-06 | FJ90.4.11.2.1.2 | 5.44d | 0d | QC [9 h] |
|  | 2 | **Installation** |  | 2024-08-18 | 2024-09-03 |  |  |  |  |
| FJ90.4.11.2.2.1 |  | Scaffolding | 2d | 2024-08-18 | 2024-08-20 | FJ90.4.11.1.1.3 | 5.44d | 0d | Scaffolding Team [18 h] |
| FJ90.4.11.2.2.2 |  | Assembly | 6d | 2024-08-20 | 2024-08-26 | FJ90.4.11.2.2.1 | 5.44d | 0d | Fitter [54 h]; Helper [54 h] |
| FJ90.4.11.2.2.3 |  | Welding | 6d | 2024-08-26 | 2024-09-01 | FJ90.4.11.2.2.2 | 5.44d | 0d | Welder [72 h]; Helper [72 h] |
| FJ90.4.11.2.2.4 |  | NDT/QC | 2d | 2024-09-01 | 2024-09-03 | FJ90.4.11.2.2.3 | 5.44d | 0d | QC [18 h] |
|  | 12 | **Leg Arrangement** |  | 2024-09-10 | 2024-09-21 |  |  |  |  |
|  | 1 | **Installation** |  | 2024-09-10 | 2024-09-21 |  |  |  |  |
| FJ90.4.12.1.1 |  | Scaffolding | 2d | 2024-09-10 | 2024-09-12 | FJ90.3.12.1.4 | 1.22d | 0d | Scaffolding Team [18 h] |
| FJ90.4.12.1.2 |  | Assembly | 3d | 2024-09-12 | 2024-09-15 | FJ90.4.12.1.1 | 1.22d | 0d | Fitter [40 h]; Helper [40 h] |
| FJ90.4.12.1.3 |  | Welding | 4.44d | 2024-09-15 | 2024-09-19 | FJ90.4.12.1.2 | 1.22d | 0d | Welder [40 h]; Helper [40 h] |
| FJ90.4.12.1.4 |  | NDT/QC | 2d | 2024-09-19 | 2024-09-21 | FJ90.4.12.1.3 | 1.22d |  | QC [18 h] |
|  | 14 | **Lifting Pad Eye** |  | 2024-09-05 | 2024-09-11 |  |  |  |  |
|  | 3 | **Installation** |  | 2024-09-05 | 2024-09-11 |  |  |  |  |
| FJ90.4.14.3.1 |  | Scaffolding | 2d | 2024-09-05 | 2024-09-07 | FJ90.3.14.3.1 | 4d | 0d | Scaffolding Team [18 h] |
| FJ90.4.14.3.2 |  | Assembly | 2d | 2024-09-07 | 2024-09-09 | FJ90.4.14.3.1 | 4d | 0d | Fitter [18 h]; Helper [18 h] |
| FJ90.4.14.3.3 |  | Welding | 2d | 2024-09-09 | 2024-09-11 | FJ90.4.14.3.2 | 4d | 0d | Welder [18 h]; Helper [18 h] |
| FJ90.4.14.3.4 |  | NDT/QC | 1d | 2024-09-11 | 2024-09-11 | FJ90.4.14.3.3 | 4d | 0d | QC [9 h] |

| ID | WBS | Activity | Duration | Start | Finish | Predecessors | Total float | Free float | Resources |
| --- | --- | --- | --- | --- | --- | --- | --- | --- | --- |
|  | 15 | **Mud Mat** |  | 2024-09-07 | 2024-09-22 |  |  |  |  |
|  | 1 | **Installation** |  | 2024-09-07 | 2024-09-22 |  |  |  |  |
| FJ90.4.15.1.1 |  | Scaffolding | 2d | 2024-09-07 | 2024-09-09 | FJ90.3.15.1.1 | 0d |  | Scaffolding Team [18 h] |
| FJ90.4.15.1.2 |  | Assembly | 4d | 2024-09-09 | 2024-09-12 | FJ90.4.15.1.1 | 0d |  | Fitter [36 h]; Helper [36 h] |
| FJ90.4.15.1.3 |  | Welding | 8d | 2024-09-12 | 2024-09-20 | FJ90.4.15.1.2 | 0d |  | Welder [72 h]; Helper [72 h] |
| FJ90.4.15.1.4 |  | NDT/QC | 2d | 2024-09-20 | 2024-09-22 | FJ90.4.15.1.3 | 0d |  | QC [18 h] |
|  | 20 | **Stabbing Cone** |  | 2024-08-29 | 2024-09-22 |  |  |  |  |
|  | 1 | **Fabrication** |  | 2024-08-29 | 2024-09-08 |  |  |  |  |
| FJ90.4.20.1.1 |  | Assembly | 3d | 2024-08-29 | 2024-09-01 | FJ90.3.20.2.3, FJ90.3.20.2.4 | 0.44d | 0d | Fitter [27 h]; Helper [27 h] |
| FJ90.4.20.1.2 |  | Welding | 6d | 2024-09-01 | 2024-09-07 | FJ90.4.20.1.1 | 0.44d | 0d | Welder [54 h]; Helper [54 h] |
| FJ90.4.20.1.3 |  | NDT/Qc | 2d | 2024-09-07 | 2024-09-08 | FJ90.4.20.1.2 | 0.44d | 0d | QC [9 h] |
|  | 2 | **Installation** |  | 2024-09-08 | 2024-09-22 |  |  |  |  |
| FJ90.4.20.2.1 |  | Scaffolding | 2d | 2024-09-08 | 2024-09-10 | FJ90.4.20.1.3 | 0.44d | 0d | Scaffolding Team [18 h] |
| FJ90.4.20.2.2 |  | Assembly | 4d | 2024-09-10 | 2024-09-14 | FJ90.4.20.1.3, FJ90.4.20.2.1 | 0.44d | 0d | Fitter [36 h]; Helper [36 h] |
| FJ90.4.20.2.3 |  | Welding | 6d | 2024-09-14 | 2024-09-20 | FJ90.4.20.2.2 | 0.44d | 0d | Welder [72 h]; Helper [72 h] |
| FJ90.4.20.2.4 |  | NDT/QC | 2d | 2024-09-20 | 2024-09-22 | FJ90.4.20.2.3 | 0.44d |  | QC [18 h] |
|  | 21 | **Rigging Platform** |  | 2024-09-03 | 2024-09-20 |  |  |  |  |
|  | 1 | **Fabrication** |  | 2024-09-03 | 2024-09-18 |  |  |  |  |
| FJ90.4.21.1.1 |  | Assembly | 7d | 2024-09-03 | 2024-09-10 | FJ90.3.21.1.1 | 2d | 0d | Fitter [63 h]; Helper [63 h] |
| FJ90.4.21.1.2 |  | Welding | 7d | 2024-09-10 | 2024-09-16 | FJ90.4.21.1.1 | 2d | 0d | Welder [63 h]; Helper [63 h] |
| FJ90.4.21.1.3 |  | NDT/QC | 2d | 2024-09-16 | 2024-09-18 | FJ90.4.21.1.2 | 2d | 0d | QC [18 h] |
|  | 2 | **Installation** |  | 2024-09-18 | 2024-09-20 |  |  |  |  |
| FJ90.4.21.2.1 |  | Trial | 2d | 2024-09-18 | 2024-09-20 | FJ90.4.21.1.3, FJ90.3.21.2.1 | 2d |  | Fitter [18 h]; QC [18 h] |
|  | 22 | **Upending Pad eye** |  | 2024-09-12 | 2024-09-18 |  |  |  |  |
|  | 2 | **Installation** |  | 2024-09-12 | 2024-09-18 |  |  |  |  |
| FJ90.4.22.2.1 |  | Scaffolding | 2d | 2024-09-12 | 2024-09-14 | FJ90.3.22.2.1, FJ90.4.14.3.4 | 4d | 0d | Scaffolding Team [18 h] |
| FJ90.4.22.2.2 |  | Assembly | 2d | 2024-09-14 | 2024-09-15 | FJ90.4.22.2.1 | 4d | 0d | Fitter [18 h]; Helper [18 h] |
| FJ90.4.22.2.3 |  | Welding | 2d | 2024-09-16 | 2024-09-17 | FJ90.4.22.2.2 | 4d | 0d | Welder [18 h]; Helper [18 h] |
| FJ90.4.22.2.4 |  | NDT/QC | 1d | 2024-09-17 | 2024-09-18 | FJ90.4.22.2.3 | 4d |  | QC [9 h] |

| ID | WBS | Activity | Duration | Start | Finish | Predecessors | Total float | Free float | Resources |
| --- | --- | --- | --- | --- | --- | --- | --- | --- | --- |
|  | 23 | **Pile Make up** |  | 2024-09-17 | 2024-09-22 |  |  |  |  |
|  | 1 | **Fabrication** |  | 2024-09-17 | 2024-09-22 |  |  |  |  |
| FJ90.4.23.1.1 |  | Assembly | 2d | 2024-09-17 | 2024-09-19 | FJ90.3.23.1.1 SS | 0d |  | Fitter [18 h]; Helper [18 h] |
| FJ90.4.23.1.2 |  | Welding | 2d | 2024-09-19 | 2024-09-21 | FJ90.4.23.1.1 | 0d |  | Welder [18 h]; Helper [18 h] |
| FJ90.4.23.1.3 |  | NDT/QC | 1d | 2024-09-21 | 2024-09-22 | FJ90.4.23.1.2 | 0d |  | QC [9 h] |
|  | 24 | **Flooding System & Leg Air Testing** |  | 2024-09-22 | 2024-09-24 |  |  |  |  |
| FJ90.4.24.1 |  | Test | 2d | 2024-09-22 | 2024-09-24 | FJ90.4.2.1.2, FJ90.4.2.2.3, FJ90.4.3.3.5, FJ90.4.4.2.4, FJ90.4.5.1.2.3, FJ90.4.6.1.2, FJ90.4.7.1.2.4, FJ90.4.8.2.4, FJ90.4.9.2, FJ90.4.10.2.4, FJ90.4.11.1.2.4, FJ90.4.12.1.4, FJ90.4.14.3.4, FJ90.4.15.1.4, FJ90.4.20.2.4, FJ90.4.21.2.1, FJ90.4.22.2.4, FJ90.4.23.1.3, FJ90.4.26.2.4, FJ90.4.27.1.3 | 0d |  | QC [72 h]; Welder [72 h]; Grinder [72 h]; Helper [72 h] |
|  | 25 | **Stair Between Boat Landing & Walk Deck** |  | 2024-09-09 | 2024-09-28 |  |  |  |  |
|  | 1 | **Fabrication** |  | 2024-09-09 | 2024-09-18 |  |  |  |  |
| FJ90.4.25.1.1 |  | Assembly | 3d | 2024-09-09 | 2024-09-12 | FJ90.4.7.2.2.4, FJ90.4.26.1.4 | 3.67d | 0d | Fitter [27 h]; Helper [27 h] |
| FJ90.4.25.1.2 |  | Welding | 4d | 2024-09-12 | 2024-09-16 | FJ90.4.25.1.1 | 3.67d | 0d | Welder [36 h]; Helper [36 h] |
| FJ90.4.25.1.3 |  | NDT/QC | 2d | 2024-09-16 | 2024-09-18 | FJ90.4.25.1.2 | 3.67d | 0d | QC [18 h] |
|  | 2 | **Installation** |  | 2024-09-18 | 2024-09-28 |  |  |  |  |
| FJ90.4.25.2.1 |  | Scaffolding | 2d | 2024-09-18 | 2024-09-19 | FJ90.4.25.1.3 | 3.67d | 0d | Scaffolding Team [18 h] |
| FJ90.4.25.2.2 |  | Assembly | 3d | 2024-09-19 | 2024-09-22 | FJ90.4.25.2.1 | 3.67d | 0d | Fitter [27 h]; Helper [27 h] |
| FJ90.4.25.2.3 |  | Welding | 4d | 2024-09-23 | 2024-09-26 | FJ90.4.25.2.2 | 3.67d | 0d | Welder [36 h]; Helper [36 h] |
| FJ90.4.25.2.4 |  | NDT/QC | 2d | 2024-09-26 | 2024-09-28 | FJ90.4.25.2.3 | 3.67d |  | QC [18 h] |
|  | 26 | **Temporary Drilling Deck** |  | 2024-08-22 | 2024-09-21 |  |  |  |  |
|  | 1 | **Fabrication** |  | 2024-08-22 | 2024-09-09 |  |  |  |  |
| FJ90.4.26.1.1 |  | Leveling | 1d | 2024-08-22 | 2024-08-23 | FJ90.3.13.2.5, FJ90.4.26.1.2 SF | 41.67d |  | Fitter [9 h] |
| FJ90.4.26.1.2 |  | Assembly | 6d | 2024-08-23 | 2024-08-29 | FJ90.4.26.1.3 SF | 35.67d | 0d | Fitter [54 h]; Helper [54 h] |
| FJ90.4.26.1.3 |  | Welding | 10d | 2024-08-29 | 2024-09-07 | FJ90.4.26.1.4 SF | 10.67d | 0d | Welder [90 h]; Helper [90 h] |
| FJ90.4.26.1.4 |  | QC | 2d | 2024-09-07 | 2024-09-09 | FJ90.4.26.2.1 SF | 3.67d | 0d | QC [18 h] |
|  | 2 | **Installation** |  | 2024-09-09 | 2024-09-21 |  |  |  |  |
| FJ90.4.26.2.1 |  | Scaffolding | 2d | 2024-09-09 | 2024-09-11 | FJ90.4.7.1.2.4 | 0.78d | 0d | Scaffolding Team [18 h] |
| FJ90.4.26.2.2 |  | Assembly | 4.44d | 2024-09-11 | 2024-09-15 | FJ90.4.26.2.1 | 0.78d | 0d | Fitter [40 h]; Helper [40 h] |
| FJ90.4.26.2.3 |  | Welding | 4.44d | 2024-09-15 | 2024-09-19 | FJ90.4.26.2.2 | 0.78d | 0d | Welder [40 h]; Helper [40 h] |
| FJ90.4.26.2.4 |  | NDT/QC | 2d | 2024-09-19 | 2024-09-21 | FJ90.4.26.2.3 | 0.78d |  | QC [18 h] |

| ID | WBS | Activity | Duration | Start | Finish | Predecessors | Total float | Free float | Resources |
| --- | --- | --- | --- | --- | --- | --- | --- | --- | --- |
|  | 27 | **Conductor Make up** |  | 2024-09-07 | 2024-09-12 |  |  |  |  |
|  | 1 | **Fabrication** |  | 2024-09-07 | 2024-09-12 |  |  |  |  |
| FJ90.4.27.1.1 |  | Assembly | 2d | 2024-09-07 | 2024-09-09 | FJ90.4.26.1.3 | 10.67d | 0d | Fitter [18 h]; Helper [18 h] |
| FJ90.4.27.1.2 |  | Welding | 2d | 2024-09-09 | 2024-09-11 | FJ90.4.27.1.1 | 10.67d | 0d | Welder [18 h]; Helper [18 h] |
| FJ90.4.27.1.3 |  | NDT/QC | 1d | 2024-09-11 | 2024-09-12 | FJ90.4.27.1.2 | 10.67d |  | QC [9 h] |
|  | 5 | **Cleaning of Barges Carrying Jacket, Piles and TDD** |  | 2024-09-25 | 2024-09-29 |  |  |  |  |
| FJ90.5.1 |  | Cleaning | 4d | 2024-09-25 | 2024-09-29 | FJ90.1.3 FS-7d, FJ90.1.4 FS-7d | 0d |  | Helper [90 h] |
|  | 6 | **Carrying out Bracing of Jackets, Pile and TDD** |  | 2024-09-29 | 2024-10-02 |  |  |  |  |
| FJ90.6.1 |  | Carry out | 3d | 2024-09-29 | 2024-10-02 | FJ90.5.1 | 0d |  |  |
|  | 7 | **Demobilization** |  | 2024-10-02 | 2024-10-02 |  |  |  |  |
| FJ90.7.1 |  | Demobilization | 0d | 2024-10-02 | 2024-10-02 | FJ90.6.1 | 0d |  | Helper |
