# برنامه کارهای باقی مانده

Schedule from MS Project, 2025-04-13 to 2025-08-02, status date 2025-04-13.

## Calendars

- Calendar 1: Mon-Sun 08:00-12:00, 13:00-17:00.

## Resources

| Resource |
| --- |
| تیم مونتاژ |
| تیم جوشکار |
| جرثقیل 60 تن |
| جرثقیل کوبلکو |

## Schedule

| ID | WBS | Task | Type | Duration | Start | Finish | Predecessors | Total slack | Free slack | Constraint | Resources | Work |
| --- | --- | --- | --- | --- | --- | --- | --- | --- | --- | --- | --- | --- |
| 1 | 1 | **Jacket remain work (2 months)** |  | 112d | 2025-04-13 | 2025-08-02 |  | 0d |  |  |  | 5840h |
| 2 | 1.1 | Start | milestone | 0d | 2025-04-13 | 2025-04-13 |  | 19d | 0d |  |  |  |
| 3 | 1.2 | Finish | milestone | 0d | 2025-08-02 | 2025-08-02 | 17, 44 | 0d |  |  |  |  |
| 4 | 1.3 | **shortage material** |  | 27d | 2025-04-18 | 2025-05-15 |  | 13d |  |  |  |  |
| 5 | 1.3.1 | Anode | milestone | 0d | 2025-05-15 | 2025-05-15 | 13 | 13d | 0d |  |  |  |
| 6 | 1.3.2 | Caisson-big support | milestone | 0d | 2025-04-28 | 2025-04-28 |  | 20d | 0d | start no earlier than 2025-04-28 |  |  |
| 7 | 1.3.3 | walk way , handrail , Stair and Grating | milestone | 0d | 2025-04-21 | 2025-04-21 |  | 42d | 0d | start no earlier than 2025-04-21 |  |  |
| 8 | 1.3.4 | Lifting and Upending Pad eye | milestone | 0d | 2025-04-21 | 2025-04-21 | 7 | 42d | 0d |  |  |  |
| 9 | 1.3.5 | Stabbing cone&Pin | milestone | 0d | 2025-04-21 | 2025-04-21 | 8 | 42d | 3d |  |  |  |
| 10 | 1.3.6 | rigging Platform | milestone | 0d | 2025-04-21 | 2025-04-21 |  | 32d | 0d | start no earlier than 2025-04-21 |  |  |
| 11 | 1.3.7 | crown Shim plate | milestone | 0d | 2025-04-21 | 2025-04-21 |  | 44d |  | start no earlier than 2025-04-21 |  |  |
| 12 | 1.3.8 | lifting and Upending Pad eye | milestone | 0d | 2025-04-21 | 2025-04-21 |  | 104d |  | start no earlier than 2025-04-21 |  |  |
| 13 | 1.3.9 | **Milestones** |  | 27d | 2025-04-18 | 2025-05-15 |  | 13d | 0d |  |  |  |
| 14 | 1.3.9.1 | buoyancy tank | milestone | 0d | 2025-05-15 | 2025-05-15 |  | 0d |  | start no earlier than 2025-05-15 |  |  |
| 15 | 1.3.9.2 | Riser 6" & Riser clamp coating | milestone | 0d | 2025-04-18 | 2025-04-18 |  | 13d | 0d | start no earlier than 2025-04-18 |  |  |
| 16 | 1.3.9.3 | weighing | milestone | 0d | 2025-05-01 | 2025-05-01 |  | 27d | 0d | start no earlier than 2025-05-01 |  |  |
| 17 | 1.4 | **FXA** |  | 112d | 2025-04-13 | 2025-08-02 |  | 0d |  |  |  | 2784h |
| 18 | 1.4.1 | Leg Arrangement |  | 5d | 2025-05-14 | 2025-05-18 | 45 | 70d |  |  | جرثقیل 60 تن | 40h |
| 19 | 1.4.2 | Row 1 |  | 10d | 2025-04-23 | 2025-05-02 | 20 | 60d | 0d |  | جرثقیل 60 تن | 80h |
| 20 | 1.4.3 | Row 2 |  | 10d | 2025-04-13 | 2025-04-22 | 2 | 60d | 0d |  | جرثقیل 60 تن | 80h |
| 21 | 1.4.4 | LEVEL 1 EL.+6.000 |  | 5d | 2025-05-03 | 2025-05-07 | 19 | 60d | 12d |  |  |  |
| 22 | 1.4.5 | Riser construction |  | 9d | 2025-04-27 | 2025-05-05 | 15, 46 | 51d | 0d |  | تیم جوشکار; تیم مونتاژ | 144h |
| 23 | 1.4.6 | Riser & Riser clamp Installation |  | 10d | 2025-05-10 | 2025-05-19 | 38, 47 | 48d | 24d |  | جرثقیل کوبلکو | 80h |
| 24 | 1.4.7 | Jtube |  | 15d | 2025-04-20 | 2025-05-04 | 48 | 63d | 15d |  | جرثقیل 60 تن | 120h |
| 25 | 1.4.8 | Caisson |  | 12d | 2025-05-03 | 2025-05-14 | 49 | 53d | 5d |  | تیم جوشکار; تیم مونتاژ; جرثقیل 60 تن | 288h |
| 26 | 1.4.9 | Anode installation |  | 7d | 2025-05-25 | 2025-05-31 | 50 | 24d | 0d |  | تیم مونتاژ; جرثقیل 60 تن; تیم جوشکار; جرثقیل کوبلکو | 192h |
| 27 | 1.4.10 | Barge bumper |  | 5d | 2025-04-29 | 2025-05-03 | 51 | 64d | 16d |  | تیم جوشکار; تیم مونتاژ; جرثقیل کوبلکو | 120h |
| 28 | 1.4.11 | Boat landing |  | 5d | 2025-04-24 | 2025-04-28 | 52 | 90d |  |  | تیم جوشکار; تیم مونتاژ; جرثقیل کوبلکو; جرثقیل 60 تن | 160h |
| 29 | 1.4.12 | Stabbing Cone |  | 5d | 2025-04-29 | 2025-05-03 | 9, 53 | 85d |  |  | تیم جوشکار; تیم مونتاژ | 80h |
| 30 | 1.4.13 | Buoyancy Tanks installation |  | 3d | 2025-07-05 | 2025-07-07 | 39 | 20d |  |  | تیم جوشکار; تیم مونتاژ; جرثقیل کوبلکو | 72h |
| 31 | 1.4.14 | Crown Shim plate |  | 3d | 2025-06-07 | 2025-06-09 | 11, 55 | 48d |  |  | تیم جوشکار; تیم مونتاژ | 48h |
| 32 | 1.4.15 | Flooding system |  | 10d | 2025-04-22 | 2025-05-01 | 56 | 55d | 0d |  | تیم جوشکار; تیم مونتاژ; جرثقیل 60 تن; جرثقیل کوبلکو | 320h |
| 33 | 1.4.16 | Lifting and Upending Pad eye |  | 9d | 2025-05-04 | 2025-05-12 | 57 | 64d | 0d |  | تیم جوشکار; تیم مونتاژ; جرثقیل 60 تن; جرثقیل کوبلکو | 288h |
| 34 | 1.4.17 | Rigging Platform |  | 7d | 2025-05-01 | 2025-05-07 | 10, 58 | 76d | 0d |  | تیم جوشکار; تیم مونتاژ; جرثقیل کوبلکو; جرثقیل 60 تن | 224h |
| 35 | 1.4.18 | walk way , handrail , Stair and Grating |  | 6d | 2025-05-04 | 2025-05-09 | 60 | 58d | 10d |  | تیم جوشکار; تیم مونتاژ | 96h |
| 36 | 1.4.19 | Painting |  | 15d | 2025-05-20 | 2025-06-03 | 20, 19, 21, 23, 24, 25, 27, 35, 40 | 48d | 28d |  | جرثقیل 60 تن [66.7%]; جرثقیل کوبلکو [66.7%] | 160h |
| 37 | 1.4.20 | Fabrication & Marking Of "Piles" |  | 5d | 2025-05-06 | 2025-05-10 | 62 | 78d |  |  | تیم جوشکار [60%]; تیم مونتاژ [60%] | 48h |
| 38 | 1.4.21 | "Riser 6",8"&12 Inches " Hydro Test |  | 1d | 2025-05-06 | 2025-05-06 | 22, 63 | 51d | 3d |  |  | 24h |
| 39 | 1.4.22 | "Buoyancy Tank" Repair & Air test |  | 3d | 2025-07-02 | 2025-07-04 | 71FS+13d, 36 | 20d | 0d |  |  | 24h |
| 40 | 1.4.23 | "Flooding System &Legs" Air Test |  | 1d | 2025-05-02 | 2025-05-02 | 32, 65 | 65d | 17d |  |  | 24h |
| 41 | 1.4.24 | load out | milestone | 0d | 2025-07-27 | 2025-07-27 | 71FS+39d, 36, 30, 18, 19, 20, 21, 22, 23, 24, 25, 26, 27, 28, 29, 31, 32, 33, 34, 35, 38, 37, 39, 40 | 0d |  |  |  |  |
| 42 | 1.4.25 | SeafastenningOperation "Jacket" |  | 3d | 2025-07-28 | 2025-07-30 | 41 | 0d |  |  | تیم مونتاژ; تیم جوشکار | 48h |
| 43 | 1.4.26 | SeafastenningOperation " Piles" |  | 3d | 2025-07-31 | 2025-08-02 | 42 | 0d |  |  |  | 24h |

Notes:
- 27: نصب ی ساپورت باقی مانده
- 29: تامی متریل
- 33: تامی متریل و وزن کشی
- 34: به محض اخذ تاییی کارفرما
- 35: TDD Stair
- 39: تعیی تکلی کارفرما

| ID | WBS | Task | Type | Duration | Start | Finish | Predecessors | Total slack | Free slack | Resources | Work |
| --- | --- | --- | --- | --- | --- | --- | --- | --- | --- | --- | --- |
| 44 | 1.5 | **F19** |  | 67d | 2025-04-13 | 2025-06-18 |  | 0d |  |  | 3056h |
| 45 | 1.5.1 | Leg Arrangement |  | 4d | 2025-05-10 | 2025-05-13 | 47 | 24d | 0d | جرثقیل 60 تن | 32h |
| 46 | 1.5.2 | Riser construction |  | 9d | 2025-04-18 | 2025-04-26 | 15 | 13d | 0d | تیم جوشکار; تیم مونتاژ; جرثقیل 60 تن | 216h |
| 47 | 1.5.3 | Riser & Riser clamp Installation |  | 10d | 2025-04-30 | 2025-05-09 | 63 | 13d | 0d | جرثقیل کوبلکو | 80h |
| 48 | 1.5.4 | J-tube |  | 7d | 2025-04-13 | 2025-04-19 | 2 | 28d | 0d | جرثقیل 60 تن | 56h |
| 49 | 1.5.5 | Caisson |  | 5d | 2025-04-28 | 2025-05-02 | 6, 48 | 20d | 7d | تیم جوشکار; تیم مونتاژ; جرثقیل 60 تن | 120h |
| 50 | 1.5.6 | Anode |  | 10d | 2025-05-15 | 2025-05-24 | 5 | 13d | 0d | تیم جوشکار; تیم مونتاژ; جرثقیل 60 تن; جرثقیل کوبلکو | 320h |
| 51 | 1.5.7 | Barge bumper |  | 10d | 2025-04-19 | 2025-04-28 | 59 | 19d | 0d | تیم جوشکار; تیم مونتاژ; جرثقیل کوبلکو | 240h |
| 52 | 1.5.8 | Boat landing |  | 4d | 2025-04-20 | 2025-04-23 | 2, 48 | 39d | 0d | تیم جوشکار; تیم مونتاژ; جرثقیل 60 تن; جرثقیل کوبلکو | 128h |
| 53 | 1.5.9 | Stabbing cone & Pin |  | 5d | 2025-04-24 | 2025-04-28 | 9, 52 | 39d | 0d | تیم جوشکار; تیم مونتاژ | 80h |
| 54 | 1.5.10 | Buoyancy Tanks |  | 20d | 2025-05-15 | 2025-06-03 | 14 | 0d |  | تیم جوشکار; تیم مونتاژ; جرثقیل کوبلکو | 480h |
| 55 | 1.5.11 | Crown Shim plate |  | 3d | 2025-06-04 | 2025-06-06 | 11, 54 | 0d |  | تیم مونتاژ | 24h |
| 56 | 1.5.12 | Flooding system |  | 9d | 2025-04-13 | 2025-04-21 | 2 | 30d | 0d | تیم جوشکار; تیم مونتاژ; جرثقیل 60 تن | 216h |
| 57 | 1.5.13 | Lifting and Upending Pad eye |  | 3d | 2025-05-01 | 2025-05-03 | 16 | 34d | 0d | تیم جوشکار; تیم مونتاژ; جرثقیل 60 تن; جرثقیل کوبلکو | 96h |
| 58 | 1.5.14 | Rigging Platform |  | 10d | 2025-04-21 | 2025-04-30 | 10 | 32d | 0d | تیم جوشکار; تیم مونتاژ; جرثقیل 60 تن; جرثقیل کوبلکو | 320h |
| 59 | 1.5.15 | TDD |  | 6d | 2025-04-13 | 2025-04-18 | 2 | 19d | 0d | تیم جوشکار; تیم مونتاژ | 96h |
| 60 | 1.5.16 | walk way , handrail , Stair and Grating |  | 5d | 2025-04-29 | 2025-05-03 | 51 | 19d | 0d | تیم جوشکار; تیم مونتاژ | 80h |
| 61 | 1.5.17 | Painting |  | 15d | 2025-05-10 | 2025-05-24 | 59, 51, 48, 49, 60, 47, 65 | 13d |  | جرثقیل 60 تن [66.7%]; جرثقیل کوبلکو [66.7%] | 160h |
| 62 | 1.5.18 | Fabrication & Marking Of "F19-Piles" |  | 5d | 2025-05-01 | 2025-05-05 | 58 | 32d | 0d | تیم جوشکار [60%]; تیم مونتاژ [60%] | 48h |
| 63 | 1.5.19 | "Riser 6",8"&12 Inches " Hydro Test |  | 3d | 2025-04-27 | 2025-04-29 | 46 | 13d | 0d |  | 24h |
| 64 | 1.5.20 | "Buoyancy Tank" Air Test |  | 1d | 2025-06-04 | 2025-06-04 | 54 | 2d |  |  | 24h |
| 65 | 1.5.21 | "Flooding System &Legs" Air Test |  | 1d | 2025-04-22 | 2025-04-22 | 56 | 30d | 9d |  | 24h |
| 66 | 1.5.22 | load out | milestone | 0d | 2025-06-06 | 2025-06-06 | 61, 45, 46, 47, 48, 49, 50, 51, 52, 53, 54, 55, 56, 57, 58, 59, 60, 62, 63, 64, 65 | 0d |  |  |  |
| 67 | 1.5.23 | Seafastenning-Operation "Jacket" |  | 3d | 2025-06-07 | 2025-06-09 | 66 | 0d |  | تیم جوشکار; تیم مونتاژ | 48h |
| 68 | 1.5.24 | Seafastenning-Operation " Piles" |  | 3d | 2025-06-10 | 2025-06-12 | 67 | 0d |  | تیم جوشکار; تیم مونتاژ | 48h |
| 69 | 1.5.25 | Seafastenning-Operation " TDD" |  | 3d | 2025-06-13 | 2025-06-15 | 68 | 0d |  | تیم جوشکار; تیم مونتاژ | 48h |
| 70 | 1.5.26 | Seafastenning-Operation " conductor pipe" |  | 3d | 2025-06-16 | 2025-06-18 | 69 | 0d |  | تیم جوشکار; تیم مونتاژ | 48h |
| 71 | 1.5.27 | delivery | milestone | 0d | 2025-06-18 | 2025-06-18 | 70 | 0d |  |  |  |

Notes:
- 53: تامی متریل
- 54: تعیی تکلی کارفرما
- 57: تامی متریل و وزن کشی
- 58: به محض اخذ تاییی کارفرما
- 60: TDD Stair
